# Sphere sched

Schedule from MS Project, 2007-10-31 to 2008-09-23.
MBARI

## Calendars

- Standard: Mon-Fri 08:00-12:00, 13:00-17:00; Sat-Sun off.

## Schedule

| ID | WBS | Task | Type | Duration | Start | Finish | Predecessors | Total slack | Constraint |
| --- | --- | --- | --- | --- | --- | --- | --- | --- | --- |
| 1 | 1 | **4kHousing** |  | 235d | 2007-10-31 | 2008-09-23 |  | 0d |  |
| 2 | 1.1 | Order | milestone | 0d | 2007-10-31 | 2007-10-31 |  | 0d | start no earlier than 2007-10-31 |
| 3 | 1.2 | Casting |  | 120d | 2007-10-31 | 2008-04-15 | 2 | 0d |  |
| 4 | 1.3 | X-ray |  | 15d | 2008-04-16 | 2008-05-06 | 3 | 0d |  |
| 5 | 1.4 | Shipping |  | 5d | 2008-05-07 | 2008-05-13 | 4 | 0d |  |
| 6 | 1.5 | Machining |  | 40d | 2008-05-14 | 2008-07-08 | 5 | 0d |  |
| 7 | 1.6 | Shipping |  | 5d | 2008-07-09 | 2008-07-15 | 6 | 0d |  |
| 8 | 1.7 | Make wood filler |  | 20d | 2008-06-09 | 2008-07-04 |  | 7d | start no earlier than 2008-06-08 |
| 9 | 1.8 | Assemble |  | 5d | 2008-07-16 | 2008-07-22 | 8, 7 | 0d |  |
| 10 | 1.9 | Hydrotest |  | 5d | 2008-07-23 | 2008-07-29 | 9 | 0d |  |
| 11 | 1.10 | Cruise prep time |  | 40d | 2008-07-30 | 2008-09-23 | 10 | 0d |  |
